# VOORBEREIDING ONDERBOUWFASE

Schedule from MS Project, 2003-01-12 to 2003-03-12, status date 2003-01-08.
BAM Nelissen Van Egteren

## Calendars

- ALLEEN WERKDAGEN: Mon-Fri 08:30-12:30, 13:00-17:00; Sat-Sun off. Exceptions (off unless hours are given): 2003-01-11 to 2003-01-12 08:30-12:30, 13:00-17:00, 2003-01-18 to 2003-01-19 08:30-12:30, 13:00-17:00, 2003-01-25 to 2003-01-26 08:30-12:30, 13:00-17:00, 2003-02-01 to 2003-02-02 08:30-12:30, 13:00-17:00, 2003-02-08 to 2003-02-09 08:30-12:30, 13:00-17:00, 2003-02-15 to 2003-02-16 08:30-12:30, 13:00-17:00, 2003-02-22 to 2003-02-23 08:30-12:30, 13:00-17:00, 2003-03-01 to 2003-03-02 08:30-12:30, 13:00-17:00, 2003-03-08 to 2003-03-09 08:30-12:30, 13:00-17:00.

## Schedule

| ID | WBS | Task | Type | Duration | Start | Finish | Predecessors | Total slack | Free slack |
| --- | --- | --- | --- | --- | --- | --- | --- | --- | --- |
| 1 | 1 | **BETON FUNDERING** |  | 60d | 2003-01-12 | 2003-03-12 |  | 0d |  |
| 2 | 1.1 | bouwopdracht | milestone | 0d | 2003-01-12 | 2003-01-12 |  | 0d |  |
| 3 | 1.2 | **beton vormtekening** |  | 20d | 2003-01-12 | 2003-01-31 |  | 20d |  |
| 4 | 1.2.1 | betonvormtekening concept |  | 10d | 2003-01-12 | 2003-01-21 |  | 20d | 0d |
| 5 | 1.2.2 | controle vormtekeningen |  | 5d | 2003-01-22 | 2003-01-26 | 4 | 20d | 0d |
| 6 | 1.2.3 | betonvormtekening definitief |  | 5d | 2003-01-27 | 2003-01-31 | 5 | 20d | 0d |
| 7 | 1.3 | **bekistingstekening** |  | 23d | 2003-01-22 | 2003-02-13 |  | 27d |  |
| 8 | 1.3.1 | bekistingstekening concept |  | 5d | 2003-01-22 | 2003-01-26 | 4 | 32d | 0d |
| 9 | 1.3.2 | controle bekistingstekening |  | 5d | 2003-01-27 | 2003-01-31 | 8 | 32d | 0d |
| 10 | 1.3.3 | bekistingstekening definitief |  | 3d | 2003-02-01 | 2003-02-03 | 9 | 32d |  |
| 11 | 1.3.4 | levertijd bekisting |  | 10d | 2003-02-04 | 2003-02-13 | 10 | 27d | 0d |
| 12 | 1.3.5 | start bekistingswerk | milestone | 0d | 2003-02-13 | 2003-02-13 | 11 | 27d |  |
| 13 | 1.4 | **wapeningstekening** |  | 20d | 2003-02-01 | 2003-02-20 |  | 20d |  |
| 14 | 1.4.1 | wapeningstekening concept |  | 10d | 2003-02-01 | 2003-02-10 | 6 | 20d | 0d |
| 15 | 1.4.2 | controle wapeningstekening |  | 5d | 2003-02-11 | 2003-02-15 | 14 | 20d | 0d |
| 16 | 1.4.3 | wapeningstekening definitief |  | 5d | 2003-02-16 | 2003-02-20 | 15 | 20d |  |
| 17 | 1.5 | **vlechtbedrijf** |  | 25d | 2003-01-17 | 2003-02-10 |  | 0d |  |
| 18 | 1.5.1 | prijsaanvraag vlechtwerk opstellen |  | 3d | 2003-01-17 | 2003-01-19 | 2SS+5d | 0d |  |
| 19 | 1.5.2 | offertes bij vlechters aanvragen |  | 3d | 2003-01-20 | 2003-01-22 | 18 | 0d |  |
| 20 | 1.5.3 | o.a. prijsaanbieding maken |  | 7d | 2003-01-23 | 2003-01-29 | 19 | 0d |  |
| 21 | 1.5.4 | offertes vlechtwerk beoordelen |  | 3d | 2003-01-30 | 2003-02-01 | 20 | 0d |  |
| 22 | 1.5.5 | prijsonderhandeling met vlechters |  | 5d | 2003-02-02 | 2003-02-06 | 21 | 0d |  |
| 23 | 1.5.6 | onderaann.contract opstelen |  | 3d | 2003-02-07 | 2003-02-09 | 22 | 0d |  |
| 24 | 1.5.7 | opdracht aan vlechter |  | 1d | 2003-02-10 | 2003-02-10 | 23 | 0d |  |

| ID | WBS | Task | Type | Duration | Start | Finish | Predecessors | Total slack |
| --- | --- | --- | --- | --- | --- | --- | --- | --- |
| 25 | 1.6 | **buigstaten** |  | 30d | 2003-02-11 | 2003-03-12 |  | 0d |
| 26 | 1.6.1 | buigstaten concept |  | 10d | 2003-02-11 | 2003-02-20 | 24 | 0d |
| 27 | 1.6.2 | controle buigstaten |  | 5d | 2003-02-21 | 2003-02-25 | 26 | 0d |
| 28 | 1.6.3 | buigstaten definitief |  | 5d | 2003-02-26 | 2003-03-02 | 27 | 0d |
| 29 | 1.6.4 | levertijd wapening |  | 10d | 2003-03-03 | 2003-03-12 | 28 | 0d |
| 30 | 1.6.5 | start beton fundering | milestone | 0d | 2003-03-12 | 2003-03-12 | 29 | 0d |
